# TNR-HFR_PhaseCD_2014-03_MSP2007

Schedule from MS Project, 2010-04-22 to 2015-07-22, 7 hours a day.

## Calendars

- Standard: Mon-Fri 09:00-12:00, 14:00-18:00; Sat-Sun off. Exceptions (off unless hours are given): 2012-08-06 to 2012-08-24, 2012-12-24 to 2013-01-04, 2013-05-01, 2013-05-08, 2013-05-20, 2013-08-05 to 2013-08-23, 2013-11-01, 2013-11-11, 2013-12-23 to 2014-01-03, 2014-04-21, 2014-05-01, 2014-05-08, 2014-06-09, 2014-07-14, 2014-08-04 to 2014-08-22, 2014-11-11, 2014-12-22 to 2015-01-03.
- Copie de Standard: Mon-Fri 09:00-12:00, 14:00-18:00; Sat-Sun off.

## Resources

| Resource |
| --- |
| PP |
| LM |
| LG |

## Schedule

| ID | WBS | Task | Type | Duration | Start | Finish | Predecessors | Total slack | Constraint |
| --- | --- | --- | --- | --- | --- | --- | --- | --- | --- |
| 1 | 1 | **Parts procurement** |  | 484d? | 2012-07-02 | 2014-07-31 |  | 228d |  |
| 2 | 1.1 | **EQM parts** |  | 484d? | 2012-07-02 | 2014-07-31 |  | 228d |  |
| 3 | 1.1.1 | LLI parts |  | 484d? | 2012-07-02 | 2014-07-31 |  | 130d | finish no earlier than 2014-07-31 |
| 4 | 1.2 | **FM parts** |  | 484d? | 2012-07-02 | 2014-07-31 |  | 228d |  |
| 5 | 1.2.1 | LLI parts |  | 484d? | 2012-07-02 | 2014-07-31 |  | 130d | finish no earlier than 2014-07-31 |
| 6 | 2 | **Parts qualification** |  | 80d | 2014-12-03 | 2015-04-08 |  | 76d |  |
| 7 | 2.1 | Flight RAM package qualification (CQFP132) |  | 4mo | 2014-12-03 | 2015-04-08 | 70SF | 76d | start no earlier than 2014-09-15 |
| 8 | 3 | **Hardware developments** |  | 1284d? | 2010-04-22 | 2015-07-22 |  | 0d |  |
| 9 | 3.1 | **Emx and/or pre-EQMx HW design and development (if EQM supressed)** |  | 533d? | 2010-04-22 | 2012-05-07 |  | 751d |  |
| 10 | 3.1.1 | Applicable if board not already developped | milestone | 0d | 2010-04-22 | 2010-04-22 |  | 1284d |  |
| 11 | 3.1.2 | Complementary NCR investigation |  | 1d? | 2010-04-22 | 2010-04-22 |  | 1283d |  |
| 12 | 3.1.3 | H/W definition and schematics (update) |  | 70d | 2011-07-04 | 2011-10-07 |  | 902d | start no earlier than 2011-07-04 |
| 13 | 3.1.4 | PCB layout |  | 85d | 2011-05-16 | 2011-09-09 |  | 922d | start no earlier than 2011-05-16 |
| 14 | 3.1.5 | MRR (light) |  | 1d? | 2010-04-22 | 2010-04-22 |  | 1283d |  |
| 15 | 3.1.6 | PCB manufacturing |  | 10d | 2011-09-05 | 2011-09-16 |  | 917d | start no earlier than 2011-09-05 |
| 16 | 3.1.7 | FPGA ready for assembly (link with FPGA developpement) |  | 1d? | 2010-04-22 | 2010-04-22 |  | 1283d |  |
| 17 | 3.1.8 | Parts available for assembly |  | 1d? | 2010-04-22 | 2010-04-22 |  | 1283d |  |
| 18 | 3.1.9 | Parts assembly |  | 14d | 2012-04-02 | 2012-04-19 |  | 763d | start no earlier than 2012-04-02 |
| 19 | 3.1.10 | Board delivery | milestone | 1d | 2011-12-12 | 2011-12-12 |  | 856d | start no earlier than 2011-12-12 |
| 20 | 3.1.11 | TRR (light) |  | 1d? | 2010-04-22 | 2010-04-22 |  | 1283d |  |
| 21 | 3.1.12 | Board testing full fonctionnal and performance |  | 10d | 2011-05-16 | 2011-05-27 |  | 997d | start no earlier than 2011-05-16 |
| 22 | 3.1.13 | Board EMC Tests |  | 1d? | 2010-04-22 | 2010-04-22 |  | 1283d |  |
| 23 | 3.1.14 | Board thermal tests (if any) |  | 1d? | 2010-04-22 | 2010-04-22 |  | 1283d |  |
| 24 | 3.1.15 | TRB and DRB (for acceptance) |  | 1d? | 2010-04-22 | 2010-04-22 |  | 1283d |  |
| 25 | 3.1.16 | Emx ready for delivery to lesia / Cnes for complementary tests | milestone | 1d | 2012-05-07 | 2012-05-07 |  | 751d | start no earlier than 2012-05-07 |
| 26 | 3.1.17 | Applicable if board already developped | milestone | 0d | 2010-04-22 | 2010-04-22 |  | 1284d |  |
| 27 | 3.1.18 | Complementary NCR investigation |  | 1d? | 2010-04-22 | 2010-04-22 |  | 1283d |  |
| 28 | 3.1.19 | Board update |  | 1d? | 2010-04-22 | 2010-04-22 |  | 1283d |  |
| 29 | 3.1.20 | TRR (light) |  | 1d? | 2010-04-22 | 2010-04-22 |  | 1283d |  |
| 30 | 3.1.21 | Board testing full fonctionnal and performance |  | 10d | 2011-05-16 | 2011-05-27 |  | 997d | start no earlier than 2011-05-16 |
| 31 | 3.1.22 | Board EMC Tests |  | 1d? | 2010-04-22 | 2010-04-22 |  | 1283d |  |
| 32 | 3.1.23 | Board thermal tests (if any) |  | 1d? | 2010-04-22 | 2010-04-22 |  | 1283d |  |
| 33 | 3.1.24 | TRB and DRB (for acceptance) |  | 1d? | 2010-04-22 | 2010-04-22 |  | 1283d |  |

Notes:
- 1: Text30: 22/04/10 Parts procurement
- 2: Text30: 22/04/10 EQM parts
- 3: Text30: 31/07/14 LLI parts
- 4: Text30: 22/04/10 FM parts
- 5: Text30: 31/07/14 LLI parts
- 6: Text30: 22/04/10 Parts qualification
- 7: Text30: 08/04/15 Flight RAM package qualification (CQFP132)
- 8: Text30: 01/07/11 Analog front-end
- 9: Text30: 15/04/13 Hardware developments
- 10: Text30: 22/04/10 Applicable if board not already developped
- 11: Text30: 22/04/10 Complementary NCR investigation
- 12: Text30: 07/10/11 H/W definition and schematics (update)
- 13: Text30: 09/09/11 PCB layout
- 14: Text30: 22/04/10 MRR (light)
- 15: Text30: 16/09/11 PCB manufacturing
- 16: Text30: 22/04/10 FPGA ready for assembly (link with FPGA developpement)
- 17: Text30: 22/04/10 Parts available for assembly
- 18: Text30: 19/04/12 Parts assembly
- 19: Text30: 12/12/11 Board delivery
- 20: Text30: 22/04/10 TRR (light)
- 21: Text30: 27/05/11 Board testing full fonctionnal and performance
- 22: Text30: 22/04/10 Board EMC Tests
- 23: Text30: 22/04/10 Board thermal tests (if any)
- 24: Text30: 22/04/10 TRB and DRB (for acceptance)
- 25: Text30: 07/05/12 Emx ready for delivery to lesia / Cnes for complementary tests
- 26: Text30: 22/04/10 Applicable if board already developped
- 27: Text30: 22/04/10 Complementary NCR investigation
- 28: Text30: 22/04/10 Board update
- 29: Text30: 22/04/10 TRR (light)
- 30: Text30: 27/05/11 Board testing full fonctionnal and performance
- 31: Text30: 22/04/10 Board EMC Tests
- 32: Text30: 22/04/10 Board thermal tests (if any)
- 33: Text30: 22/04/10 TRB and DRB (for acceptance)

| ID | WBS | Task | Type | Duration | Start | Finish | Predecessors | Total slack | Free slack | Constraint | Calendar | Text30 |
| --- | --- | --- | --- | --- | --- | --- | --- | --- | --- | --- | --- | --- |
| 34 | 3.2 | **EQMx HW design and development** |  | 189d | 2014-04-07 | 2015-02-06 |  | 15d |  |  |  | 15/04/13 Hardware developments |
| 35 | 3.2.1 | H/W definition and schematics (update) |  | 70d | 2014-04-07 | 2014-07-18 |  | 15d |  | finish no earlier than 2014-07-18 |  | 18/07/14 H/W definition and schematics (update) |
| 36 | 3.2.2 | TCS design availability | milestone | 0d | 2014-09-01 | 2014-09-01 | 35 | 0d |  | start no earlier than 2014-09-01 |  | 01/09/14 TCS design availability |
| 37 | 3.2.3 | Request for modification redaction |  | 5d | 2014-09-01 | 2014-09-05 | 36 | 0d |  | must start on 2014-09-01 |  | 05/09/14 Request for modification redaction |
| 38 | 3.2.4 | PCB layout |  | 4w | 2014-09-08 | 2014-10-03 | 37 | 3d | 0d | start no earlier than 2011-05-16 |  | 03/10/14 PCB layout |
| 39 | 3.2.5 | MRR preparation (documentation) |  | 1d | 2014-10-06 | 2014-10-06 | 38 | 196d |  |  |  | 06/10/14 MRR preparation (documentation) |
| 40 | 3.2.6 | MRR |  | 1d | 2014-10-06 | 2014-10-06 | 38 | 3d | 0d |  |  | 06/10/14 MRR |
| 41 | 3.2.7 | PCB manufacturing |  | 4w | 2014-10-07 | 2014-11-03 | 40 | 3d | 0d | start no earlier than 2011-09-05 | Copie de Standard | 03/11/14 PCB manufacturing |
| 42 | 3.2.8 | Parts available for assembly | milestone | 0d | 2014-11-04 | 2014-11-04 | 44SS | 176d |  |  |  | 04/11/14 Parts available for assembly |
| 43 | 3.2.9 | Need date for mechanical frame | milestone | 0d | 2014-11-04 | 2014-11-04 | 44SS | 176d | 0d |  |  | 04/11/14 Need date for mechanical frame |
| 44 | 3.2.10 | Parts assembly |  | 4w | 2014-11-04 | 2014-12-02 | 41 | 3d | 0d | start no earlier than 2012-04-02 |  | 02/12/14 Parts assembly |
| 45 | 3.2.11 | Integration in mechanical frame | milestone | 0d | 2014-11-04 | 2014-11-04 | 43 | 176d |  |  |  | 04/11/14 Integration in mechanical frame |
| 46 | 3.2.12 | FPGA programming |  | 2w | 2014-11-24 | 2014-12-05 | 100, 44FF | 0d |  |  |  | 05/12/14 FPGA programming |
| 47 | 3.2.13 | FPGA validation in the dedicated socket |  | 1d | 2014-12-08 | 2014-12-08 | 44, 46 | 0d |  |  |  | 08/12/14 FPGA validation in the dedicated socket |
| 48 | 3.2.14 | FPGA ready for assembly | milestone | 0d | 2014-12-08 | 2014-12-08 | 47SF | 0d |  |  |  | 08/12/14 FPGA ready for assembly |
| 49 | 3.2.15 | FPGA soldering |  | 1w | 2014-12-08 | 2014-12-12 | 48 | 0d |  |  |  | 12/12/14 FPGA soldering |
| 50 | 3.2.16 | Board delivery | milestone | 1d | 2014-12-15 | 2014-12-15 | 49 | 0d |  | finish no earlier than 2014-12-15 |  | 15/12/14 Board delivery |
| 51 | 3.2.17 | Board testing |  | 2w | 2014-12-16 | 2015-01-12 | 50 | 0d |  |  |  | 12/01/15 Board testing |
| 52 | 3.2.18 | TRR preparation (documentation) |  | 2d | 2015-01-13 | 2015-01-14 | 51 | 0d |  |  |  | 14/01/15 TRR preparation (documentation) |
| 53 | 3.2.19 | Boards ready for MIP and TRR | milestone | 0d | 2015-01-14 | 2015-01-14 | 52 | 0d |  | start no earlier than 2013-01-18 |  | 14/01/15 Boards ready for MIP and TRR |
| 54 | 3.2.20 | TRR |  | 1d | 2015-01-15 | 2015-01-15 | 53 | 0d |  |  |  | 15/01/15 TRR |
| 55 | 3.2.21 | Board full fonctionnal and performance tests |  | 2w | 2015-01-16 | 2015-01-29 | 54 | 0d |  | start no earlier than 2011-05-16 |  | 29/01/15 Board full fonctionnal and performance tests |
| 56 | 3.2.22 | Board EMC Tests |  | 1w | 2015-01-30 | 2015-02-05 | 55 | 0d |  |  |  | 05/02/15 Board EMC Tests |
| 57 | 3.2.23 | Coating | milestone | 0w | 2015-02-05 | 2015-02-05 | 56 | 0d |  | start no earlier than 2011-05-16 |  | 05/02/15 Coating |
| 58 | 3.2.24 | Post-coating tests and characterization | milestone | 0w | 2015-02-05 | 2015-02-05 | 57 | 0d |  | start no earlier than 2011-05-16 |  | 05/02/15 Post-coating tests and characterization |
| 59 | 3.2.25 | Board thermal tests (if any) | milestone | 0d | 2015-02-05 | 2015-02-05 | 58 | 0d |  |  |  | 05/02/15 Board thermal tests (if any) |
| 60 | 3.2.26 | TRB and DRB |  | 1d | 2015-02-06 | 2015-02-06 | 59 | 0d |  |  |  | 06/02/15 TRB and DRB |
| 61 | 3.2.27 | EQMx ready for delivery to lesia for AIT MEB | milestone | 0d | 2015-02-06 | 2015-02-06 | 60 | 0d |  | start no earlier than 2012-05-07 |  | 06/02/15 EQMx ready for delivery to lesia for AIT MEB |

| ID | WBS | Task | Type | Duration | Start | Finish | Predecessors | Total slack | Constraint | Text30 |
| --- | --- | --- | --- | --- | --- | --- | --- | --- | --- | --- |
| 62 | 3.3 | **FM HW design and development** |  | 118d | 2015-02-09 | 2015-07-22 |  | 0d |  | 15/04/13 Hardware developments |
| 63 | 3.3.1 | H/W definition and schematics (update) |  | 2w | 2015-02-09 | 2015-02-20 | 61 | 0d | start no earlier than 2011-07-04 | 20/02/15 H/W definition and schematics (update) |
| 64 | 3.3.2 | PCB layout |  | 2w | 2015-02-23 | 2015-03-06 | 63 | 0d | start no earlier than 2011-05-16 | 06/03/15 PCB layout |
| 65 | 3.3.3 | MRR preparation (documentation) |  | 1d | 2015-03-09 | 2015-03-09 | 64 | 0d |  | 09/03/15 MRR preparation (documentation) |
| 66 | 3.3.4 | MRR |  | 1d | 2015-03-10 | 2015-03-10 | 65 | 0d |  | 10/03/15 MRR |
| 67 | 3.3.5 | PCB manufacturing |  | 4w | 2015-03-11 | 2015-04-07 | 66 | 0d | start no earlier than 2011-09-05 | 07/04/15 PCB manufacturing |
| 68 | 3.3.6 | Parts available for assembly | milestone | 0d | 2015-04-08 | 2015-04-08 | 70SS | 76d |  | 08/04/15 Parts available for assembly |
| 69 | 3.3.7 | Need date for mechanical frame | milestone | 0d | 2015-04-08 | 2015-04-08 | 70SS | 76d |  | 08/04/15 Need date for mechanical frame |
| 70 | 3.3.8 | Parts assembly |  | 4w | 2015-04-08 | 2015-05-05 | 67 | 0d | start no earlier than 2012-04-02 | 05/05/15 Parts assembly |
| 71 | 3.3.9 | Integration in mechanical frame | milestone | 0d | 2015-05-05 | 2015-05-05 | 70 | 0d |  | 05/05/15 Integration in mechanical frame |
| 72 | 3.3.10 | FPGA validation in the dedicated socket |  | 1d | 2015-05-06 | 2015-05-06 | 71 | 0d |  | 06/05/15 FPGA validation in the dedicated socket |
| 73 | 3.3.11 | FPGA ready for assembly | milestone | 0d | 2015-05-06 | 2015-05-06 | 72 | 0d |  | 06/05/15 FPGA ready for assembly |
| 74 | 3.3.12 | FPGA soldering |  | 1w | 2015-05-07 | 2015-05-13 | 73 | 0d |  | 13/05/15 FPGA soldering |
| 75 | 3.3.13 | Board delivery | milestone | 1d | 2015-05-14 | 2015-05-14 | 74 | 0d | start no earlier than 2011-12-12 | 14/05/15 Board delivery |
| 76 | 3.3.14 | Board testing |  | 2w | 2015-05-15 | 2015-05-28 | 75 | 0d |  | 28/05/15 Board testing |
| 77 | 3.3.15 | TRR preparation (documentation) |  | 2d | 2015-05-29 | 2015-06-01 | 76 | 0d |  | 01/06/15 TRR preparation (documentation) |
| 78 | 3.3.16 | Boards ready for MIP and TRR | milestone | 0d | 2015-06-01 | 2015-06-01 | 77 | 0d | start no earlier than 2013-01-18 | 01/06/15 Boards ready for MIP and TRR |
| 79 | 3.3.17 | TRR |  | 1d | 2015-06-02 | 2015-06-02 | 78 | 0d |  | 02/06/15 TRR |
| 80 | 3.3.18 | Board full fonctionnal and performance tests |  | 2w | 2015-06-03 | 2015-06-16 | 79 | 0d | start no earlier than 2011-05-16 | 16/06/15 Board full fonctionnal and performance tests |
| 81 | 3.3.19 | Board EMC Tests |  | 1w | 2015-06-17 | 2015-06-23 | 80 | 0d |  | 23/06/15 Board EMC Tests |
| 82 | 3.3.20 | Coating |  | 3w | 2015-06-24 | 2015-07-14 | 81 | 0d | start no earlier than 2011-05-16 | 14/07/15 Coating |
| 83 | 3.3.21 | Post-coating tests and characterization |  | 1w | 2015-07-15 | 2015-07-21 | 82 | 0d | start no earlier than 2011-05-16 | 21/07/15 Post-coating tests and characterization |
| 84 | 3.3.22 | Board thermal tests (if any) | milestone | 0d | 2015-07-21 | 2015-07-21 | 83 | 0d |  | 21/07/15 Board thermal tests (if any) |
| 85 | 3.3.23 | TRB and DRB |  | 1d | 2015-07-22 | 2015-07-22 | 84 | 0d |  | 22/07/15 TRB and DRB |
| 86 | 3.3.24 | FM ready for delivery to lesia for AIT MEB | milestone | 0d | 2015-07-22 | 2015-07-22 | 85 | 0d | start no earlier than 2012-05-07 | 22/07/15 FM ready for delivery to lesia for AIT MEB |

| ID | WBS | Task | Type | Duration | Start | Finish | Predecessors | Total slack | Free slack | Constraint |
| --- | --- | --- | --- | --- | --- | --- | --- | --- | --- | --- |
| 87 | 4 | **FPGA developments** |  | 1198d? | 2010-04-22 | 2015-03-24 |  | 86d |  |  |
| 88 | 4.1 | **Emx and/or pre-EQM firmware** |  | 378d? | 2010-04-22 | 2011-10-03 |  | 906d |  |  |
| 89 | 4.1.1 | Put detailled sequence of developpment and tests… |  | 1d? | 2010-04-22 | 2010-04-22 |  | 1283d |  |  |
| 90 | 4.1.2 | Firmware ready for Emx or pre-EQMx | milestone | 1d | 2011-10-03 | 2011-10-03 |  | 906d |  | start no earlier than 2011-10-03 |
| 91 | 4.2 | **EQMx firmware** |  | 1121d? | 2010-04-22 | 2014-11-21 |  | 163d |  |  |
| 92 | 4.2.1 | Put detailled sequence of developpment and tests… |  | 1d? | 2010-04-22 | 2010-04-22 |  | 1283d |  |  |
| 93 | 4.2.2 | VHDL: waveform picker refinement |  | 2w | 2014-08-25 | 2014-09-05 |  | 0d |  | must start on 2014-08-25 |
| 94 | 4.2.3 | VHDL: downsampling filter 24576 => 4096 |  | 2w | 2014-09-08 | 2014-09-19 | 93 | 43d | 0d |  |
| 95 | 4.2.4 | **flight RAM evaluation board** |  | 1072d? | 2010-04-22 | 2014-09-12 |  | 212d |  |  |
| 96 | 4.2.4.1 | PCB design and manufacturing |  | 1d? | 2010-04-22 | 2010-04-22 |  | 1283d |  |  |
| 97 | 4.2.4.2 | flight RAM bending and cutting |  | 2w | 2014-08-25 | 2014-09-05 |  | 38d | 0d | finish no earlier than 2014-09-05 |
| 98 | 4.2.4.3 | Board population |  | 1w | 2014-09-08 | 2014-09-12 | 97 | 38d | 0d |  |
| 99 | 4.2.5 | VHDL: flight RAM memory controler |  | 2w | 2014-09-15 | 2014-09-26 | 98 | 38d |  |  |
| 100 | 4.2.6 | Firmware ready for EQMx assembly | milestone | 1d | 2014-11-21 | 2014-11-21 | 94, 99 | 0d |  | as late as possible |
| 101 | 4.2.7 | Documentation |  | 92d | 2012-01-05 | 2012-05-11 |  | 747d |  | finish no earlier than 2012-05-11 |
| 102 | 4.3 | **FM firmware** |  | 121d | 2014-09-22 | 2015-03-24 |  | 86d |  |  |
| 103 | 4.3.1 | VHDL: downsampling filter, all frequencies |  | 12w | 2014-09-22 | 2014-12-15 | 94 | 86d | 0d |  |
| 104 | 4.3.2 | VHDL: SCM calibration |  | 4w | 2014-12-16 | 2015-01-26 | 103 | 127d |  |  |
| 105 | 4.3.3 | VHDL: housekeeping |  | 4w | 2014-12-16 | 2015-01-26 | 103 | 86d | 0d |  |
| 106 | 4.3.4 | Completion of the firmware and tests documentation |  | 4w | 2015-01-27 | 2015-02-23 | 105 | 86d | 0d | start no earlier than 2014-03-03 |
| 107 | 4.3.5 | Tests result analysis (Cnes / Lesia) |  | 1w | 2015-02-24 | 2015-03-02 | 106 | 86d | 0d |  |
| 108 | 4.3.6 | Validation KP |  | 1d | 2015-03-03 | 2015-03-03 | 107 | 86d | 0d |  |
| 109 | 4.3.7 | Complementary tests follow-up analysis |  | 1w | 2015-03-04 | 2015-03-10 | 108 | 86d | 0d |  |
| 110 | 4.3.8 | GO / NOGO FM FPGA ready for programmation | milestone | 0d | 2015-03-10 | 2015-03-10 | 109 | 86d | 0d |  |

Notes:
- 87: Text30: 07/05/12 FPGA developments
- 88: Text30: 01/07/11 FPGA firmware
- 89: Text30: 22/04/10 Put detailled sequence of developpment and tests…
- 90: Text30: 03/10/11 Firmware ready for Emx or pre-EQMx
- 91: Text30: 01/07/11 FPGA firmware
- 92: Text30: 22/04/10 Put detailled sequence of developpment and tests…
- 93: Text30: 05/09/14 VHDL: waveform picker refinement
- 94: Text30: 19/09/14 VHDL: downsampling filter 24576 => 4096
- 95: Text30: 22/04/10 flight RAM evaluation board
- 96: Text30: 22/04/10 PCB design and manufacturing
- 97: Text30: 05/09/14 flight RAM bending and cutting
- 98: Text30: 12/09/14 Board population
- 99: Text30: 26/09/14 VHDL: flight RAM memory controler
- 100: Text30: 21/11/14 Firmware ready for EQMx assembly
- 101: Text30: 11/05/12 Documentation
- 102: Text30: 01/07/11 FPGA firmware
- 103: Text30: 15/12/14 VHDL: downsampling filter, all frequencies
- 104: Text30: 26/01/15 VHDL: SCM calibration
- 105: Text30: 26/01/15 VHDL: housekeeping
- 106: Text30: 23/02/15 Completion of the firmware and tests documentation
- 107: Text30: 02/03/15 Tests result analysis (Cnes / Lesia)
- 108: Text30: 03/03/15 Validation KP
- 109: Text30: 10/03/15 Complementary tests follow-up analysis
- 110: Text30: 10/03/15 GO / NOGO FM FPGA ready for programmation

| ID | WBS | Task | Type | Duration | Start | Finish | Predecessors | Total slack | Free slack | Constraint |
| --- | --- | --- | --- | --- | --- | --- | --- | --- | --- | --- |
| 111 | 4.3.9 | **PPBI** |  | 60d | 2014-12-17 | 2015-03-24 |  | 86d |  |  |
| 112 | 4.3.9.1 | PPBI: NRE |  | 10w | 2014-12-17 | 2015-03-10 | 110FF | 96d |  |  |
| 113 | 4.3.9.2 | FPGA programmation |  | 1d | 2015-03-11 | 2015-03-11 | 110 | 86d | 0d |  |
| 114 | 4.3.9.3 | PPBI: electrical tests |  | 9d | 2015-03-12 | 2015-03-24 | 113 | 86d | 0d |  |
| 115 | 4.3.10 | Firmware ready for FM assembly | milestone | 0d | 2015-03-24 | 2015-03-24 | 114 | 86d |  | start no earlier than 2011-10-03 |
| 116 | 5 | **Onboard analyser SW (or boot for DPU) developments** |  | 1284d? | 2010-04-22 | 2015-07-22 |  | 0d |  |  |
| 117 | 5.1 | R2 : put only delivery dates and reviews dates... (because it's finished) |  | 1d? | 2010-04-22 | 2010-04-22 |  | 1283d |  |  |
| 118 | 5.2 | Software delivery to LESIA |  | 1d | 2014-06-26 | 2014-06-26 |  | 0d |  | must start on 2014-06-26 |
| 119 | 5.3 | SW CDR Data package delivery | milestone | 0d | 2014-09-15 | 2014-09-15 | 120SS-10d | 212d |  |  |
| 120 | 5.4 | SW CDR |  | 1d | 2014-09-29 | 2014-09-29 |  | 201d | 0d | start no earlier than 2014-09-29 |
| 121 | 5.5 | **R3 software (EQM & FM)** |  | 1284d? | 2010-04-22 | 2015-07-22 |  | 0d |  |  |
| 122 | 5.5.1 | Put detailled schedule including reviews… |  | 1d? | 2010-04-22 | 2010-04-22 |  | 1283d |  |  |
| 123 | 5.5.2 | R3 pre-release ready for EQM testing | milestone | 0d | 2014-12-16 | 2014-12-16 | 51SF | 147d |  |  |
| 124 | 5.5.3 | R3 pre-release ready for delivery to LESIA | milestone | 0d | 2015-02-06 | 2015-02-06 | 61SF | 118d |  |  |
| 125 | 5.5.4 | R3 ready for FM testing | milestone | 0d | 2015-05-15 | 2015-05-15 | 76SF | 49d |  |  |
| 126 | 5.5.5 | R3 ready for delivery to LESIA | milestone | 0d | 2015-07-22 | 2015-07-22 | 86SF | 0d |  |  |
| 127 | 6 | **GSE develompment** |  | 0d | 2010-04-22 | 2010-04-22 |  | 1284d |  |  |
| 128 | 6.1 | SGSE | milestone | 0d | 2010-04-22 | 2010-04-22 |  | 1284d |  |  |
| 129 | 6.2 | EGSE | milestone | 0d | 2010-04-22 | 2010-04-22 |  | 1284d |  |  |

Notes:
- 111: Text30: 22/04/10 PPBI
- 112: Text30: 10/03/15 PPBI: NRE
- 113: Text30: 11/03/15 FPGA programmation
- 114: Text30: 24/03/15 PPBI: electrical tests
- 115: Text30: 24/03/15 Firmware ready for FM assembly
- 116: Text30: 22/04/10 Onboard software developmnts
- 117: Text30: 22/04/10 R2 : put only delivery dates and reviews dates... (because it's finished)
- 118: Text30: 26/06/14 Software delivery to LESIA
- 119: Text30: 15/09/14 SW CDR Data package delivery
- 120: Text30: 29/09/14 SW CDR
- 121: Text30: 01/07/11 Software
- 122: Text30: 22/04/10 Put detailled schedule including reviews…
- 123: Text30: 16/12/14 R3 pre-release ready for EQM testing
- 124: Text30: 06/02/15 R3 pre-release ready for delivery to LESIA
- 125: Text30: 15/05/15 R3 ready for FM testing
- 126: Text30: 22/07/15 R3 ready for delivery to LESIA
- 127: Text30: 22/04/10 GSE
- 128: Text30: 22/04/10 SGSE
- 129: Text30: 22/04/10 EGSE
